# CONSERVACION TERRENO QUEBRADA PAIPA 3

Schedule from MS Project, 2021-08-02 to 2022-01-20, status date 2021-10-11, costs in $, A marks actual dates.

## Calendars

- Copia de Estándar: Mon 07:00-12:00, 13:00-17:00; Tue-Fri 07:00-13:00, 14:00-17:00; Sat-Sun off.

## Resources

| Resource | Group | Rate | Cost per use |
| --- | --- | --- | --- |
| Viaje Terrestre | transporte |  |  |
| Postes |  | 19800000 | 60000 |
| Alambre |  | 12000000 | 50000 |
| Transporte materiales |  |  |  |
| Gerente de proyecto |  | 43750 |  |
| Topógrafo |  | 21875 |  |
| Ingeniero |  | 21875 |  |
| Abogado |  | 31250 |  |
| Asistente administrativo 1 |  | 11250 |  |
| Árboles |  | 40000000 | 250000 |
| Impresión de planos |  |  |  |
| Cuadrilla 1 |  | 64375 |  |
| herramientas manuales |  |  |  |
| Ingeniero ambiental |  | 21875 |  |
| Ingeniero de suelos |  | 21875 |  |
| Ingeniero para estudios hidrológicos |  | 21875 |  |
| Asistente ingeniero 1 |  | 13750 |  |
| Laboratorio de suelos |  |  |  |
| Asistente ingeniero 2 |  | 13750 |  |
| Asistente ingeniero 3 |  | 13750 |  |
| Asistente ingeniero 4 |  | 13750 |  |
| Computadores |  |  |  |
| Mobiliario |  |  |  |
| Celular y Radioteléfono |  |  |  |
| Impresión documentos |  |  |  |
| Persona encargada compras |  | 12500 |  |
| Asistente administrativo 2 |  | 11250 |  |
| cuadrilla 2 |  | 64375 |  |

## Schedule

| ID | WBS | Task | Type | Duration | Start | Finish | Predecessors | Complete | Remaining | Baseline start | Baseline finish | Baseline duration | Total slack | Free slack | Resources | Work | Actual work | Cost | Baseline cost | Actual cost |
| --- | --- | --- | --- | --- | --- | --- | --- | --- | --- | --- | --- | --- | --- | --- | --- | --- | --- | --- | --- | --- |
| 1 | 1 | **CONSERVACION Y PROTECCION DEL PREDIO EL BANQUEO** |  | 139.38d | 2021-08-02 A | 2022-01-20 |  | 24% | 105.31d | 2021-08-02 | 2022-02-07 | 152.38d | 0d |  |  | 1986.16h | 365.4h | 386,776,914 | 386,776,914 | 50,885,993.88 |
| 2 | 1.1 | **1.1 TRAMITES LEGALES** |  | 39.38d | 2021-08-02 A | 2021-09-18 |  | 79% | 8.35d | 2021-08-02 | 2021-09-18 | 39.38d | 100d |  |  | 132h | 96h | 15,585,000 | 15,585,000 | 11,853,572 |
| 3 | 1.1.1 | **1.1.1 TITULOS LEGALES DEL PREDIO** |  | 21.5d | 2021-08-02 A | 2021-08-27 |  | 61% | 8.36d | 2021-08-02 | 2021-08-25 | 19.5d | 117.88d |  |  | 96h | 60h | 7,020,800 | 7,020,800 | 3,289,372 |
| 4 | 1.1.1.1 | Verificación de la situación actual del inmueble |  | 15d | 2021-08-02 A | 2021-08-20 |  | 67% | 5d | 2021-08-02 | 2021-08-20 | 15d | 0d |  | Abogado [50%]; Asistente administrativo 1 [20%]; Viaje Terrestre [0.1%] | 84h | 56h | 3,520,800 | 3,520,800 | 2,216,872 |
| 5 | 1.1.1.2 | Decidir sobre el predio |  | 3d | 2021-08-24 A | 2021-08-27 | 4 | 33% | 2d | 2021-08-24 | 2021-08-25 | 1d | 117.88d |  | Abogado [50%] | 12h | 4h | 3,500,000 | 3,500,000 | 1,072,500 |
| 6 | 1.1.1.3 | Hito fase 1 | milestone | 0d | 2021-08-25 A | 2021-08-25 A | 5 | 100% |  | 2021-08-25 | 2021-08-25 | 0d |  |  |  |  |  |  |  |  |
| 7 | 1.1.2 | **1.1.2 VIABILIDAD AMBIENTAL CORTOLIMA** |  | 19.88d | 2021-08-25 A | 2021-09-18 A |  | 100% |  | 2021-08-25 | 2021-09-18 | 19.88d |  |  |  | 36h | 36h | 8,564,200 | 8,564,200 | 8,564,200 |
| 8 | 1.1.2.1 | Evaluar criterios técnicos contenidos en la metodología de adquisición del predio |  | 10d | 2021-08-25 A | 2021-09-10 A | 5 | 100% |  | 2021-08-25 | 2021-09-10 | 10d |  |  | Abogado [30%]; Asistente administrativo 1 [10%] | 32h | 32h | 4,564,200 | 4,564,200 | 4,564,200 |
| 9 | 1.1.2.2 | Verificar concepto de viabilidad ambiental |  | 5d | 2021-09-10 A | 2021-09-18 A | 8 | 100% |  | 2021-09-10 | 2021-09-18 | 5d |  |  | Abogado [10%] | 4h | 4h | 4,000,000 | 4,000,000 | 4,000,000 |
| 10 | 1.1.2.3 | Hito fase 2 | milestone | 0d | 2021-09-18 A | 2021-09-18 A | 9 | 100% |  | 2021-09-18 | 2021-09-18 | 0d |  |  |  |  |  |  |  |  |
| 11 | 1.2 | **1.2 ESTUDIOS Y DISEÑOS** |  | 100d | 2021-09-18 A | 2022-01-20 |  | 27% | 73.04d | 2021-09-18 | 2022-01-20 | 100d | 0d |  |  | 894.16h | 190.2h | 44,617,150 | 44,617,150 | 12,779,046.88 |
| 12 | 1.2.1 | **1.2.1 AVALUO COMERCIAL** |  | 12.25d | 2021-09-18 A | 2021-10-04 |  | 89% | 1.36d | 2021-09-18 | 2021-10-02 | 11.25d | 12.75d |  |  | 86.4h | 84.8h | 9,500,000 | 9,500,000 | 6,502,000 |
| 13 | 1.2.1.1 | Determinar el valor comercial del predio |  | 15d | 2021-09-18 A | 2021-10-01 A | 9 | 100% |  | 2021-09-18 | 2021-10-01 | 15d |  |  | Abogado [40%]; Asistente administrativo 1 [30%] | 84h | 84h | 5,000,000 | 5,000,000 | 5,000,000 |
| 14 | 1.2.1.2 | Presentación de oferta |  | 3d | 2021-10-02 A | 2021-10-04 | 13 | 33% | 2d | 2021-10-02 | 2021-10-02 | 1d | 12.75d | 11.62d | Abogado [10%] | 2.4h | 0.8h | 4,500,000 | 4,500,000 | 1,502,000 |
| 15 | 1.2.2 | **1.2.2 DISEÑO AISLAMIENTO** |  | 12.62d | 2021-10-02 A | 2021-10-19 |  | 65% | 4.42d | 2021-10-02 | 2021-10-19 | 12.62d | 1.12d |  |  | 28h | 23.8h | 5,700,000 | 5,700,000 | 4,730,546.88 |
| 16 | 1.2.2.1 | Presentación de pliegos de condiciones del diseño |  | 8d | 2021-10-02 A | 2021-10-09 A | 9, 14 | 100% |  | 2021-10-02 | 2021-10-09 | 8d |  |  | Gerente de proyecto [10%]; Ingeniero [5%]; Asistente ingeniero 1 [10%]; Asistente administrativo 1 [10%] | 22.4h | 22.4h | 4,500,000 | 4,500,000 | 4,500,000 |
| 17 | 1.2.2.2 | Entregar planos para construcción |  | 7d | 2021-10-09 A | 2021-10-19 | 16 | 25% | 5.25d | 2021-10-09 | 2021-10-19 | 7d | 1.12d | 0d | Gerente de proyecto [5%]; Ingeniero [5%]; Impresión de planos [0.1%]; Computadores [0.1%] | 5.6h | 1.4h | 1,200,000 | 1,200,000 | 230,546.88 |
| 18 | 1.2.3 | **1.2.3 DISEÑO DE SIEMBRA** |  | 36d | 2021-10-19 | 2021-12-02 |  |  |  | 2021-10-19 | 2021-12-02 | 36d | 1.12d |  |  | 484.48h |  | 13,714,000 | 13,714,000 |  |
| 19 | 1.2.3.1 | Analizar tipos de siembra según característica del terreno |  | 5d | 2021-10-19 | 2021-10-25 | 17, 14 |  |  | 2021-10-19 | 2021-10-25 | 5d | 1.12d | 0d | Ingeniero ambiental [60%]; Viaje Terrestre [0.1%]; Gerente de proyecto [10%]; Asistente ingeniero 2 [30%] | 40h |  | 2,500,000 | 2,500,000 |  |
| 20 | 1.2.3.2 | Contratar personal para realizar estudios |  | 13.88d | 2021-10-25 | 2021-11-09 | 19 |  |  | 2021-10-25 | 2021-11-09 | 13.88d | 1.12d | 0d | Gerente de proyecto; Computadores [0.1%]; Asistente administrativo 2 | 222.08h |  | 5,430,000 | 5,430,000 |  |
| 21 | 1.2.3.3 | Realizar estudios |  | 8d | 2021-11-09 | 2021-11-18 | 20 |  |  | 2021-11-09 | 2021-11-18 | 8d | 1.12d | 0d | Ingeniero ambiental [80%]; Asistente ingeniero 2 [80%]; Computadores [0.1%] | 102.4h |  | 1,974,000 | 1,974,000 |  |
| 22 | 1.2.3.4 | Entregar estudios de análisis de siembra |  | 15d | 2021-11-18 | 2021-12-02 | 21 |  |  | 2021-11-18 | 2021-12-02 | 15d | 1.12d | 0d | Ingeniero ambiental [40%]; Asistente administrativo 1 [10%]; Gerente de proyecto [50%] | 120h |  | 3,810,000 | 3,810,000 |  |
| 23 | 1.2.4 | **1.2.4 TOPOGRAFIA** |  | 14d | 2021-12-02 | 2021-12-20 |  |  |  | 2021-12-02 | 2021-12-20 | 14d | 0.12d |  |  | 55.28h |  | 6,552,600 | 6,552,600 |  |
| 24 | 1.2.4.1 | Contratar personal para realizar estudios |  | 3d | 2021-12-02 | 2021-12-04 | 22, 14 |  |  | 2021-12-02 | 2021-12-04 | 3d | 0.12d | 0d | Gerente de proyecto [2%]; Asistente administrativo 1 [5%] | 1.68h |  | 3,000,000 | 3,000,000 |  |
| 25 | 1.2.4.2 | Realizar levantamiento de información en sitio |  | 5d | 2021-12-04 | 2021-12-10 | 24 |  |  | 2021-12-04 | 2021-12-10 | 5d | 0.12d | 0d | Topógrafo [50%]; Viaje Terrestre [0.1%] | 20h |  | 952,600 | 952,600 |  |
| 26 | 1.2.4.3 | Entregar estudios realizados |  | 7d | 2021-12-10 | 2021-12-20 | 25 |  |  | 2021-12-10 | 2021-12-20 | 7d | 0.12d | 0d | Gerente de proyecto [10%]; Topógrafo [50%]; Impresión de planos [0.1%] | 33.6h |  | 2,600,000 | 2,600,000 |  |

| ID | WBS | Task | Type | Duration | Start | Finish | Predecessors | Complete | Remaining | Baseline start | Baseline finish | Baseline duration | Total slack | Free slack | Resources | Work | Actual work | Cost | Baseline cost | Actual cost |
| --- | --- | --- | --- | --- | --- | --- | --- | --- | --- | --- | --- | --- | --- | --- | --- | --- | --- | --- | --- | --- |
| 27 | 1.2.5 | **1.2.5 SUELOS** |  | 15d | 2021-12-20 | 2022-01-06 |  |  |  | 2021-12-20 | 2022-01-06 | 15d | 0.12d |  |  | 80.8h |  | 5,827,050 | 5,827,050 |  |
| 28 | 1.2.5.1 | Contratar personal para realizar estudios |  | 3d | 2021-12-20 | 2021-12-23 | 26, 14 |  |  | 2021-12-20 | 2021-12-23 | 3d | 0.12d | 0d | Asistente administrativo 1 [10%]; Gerente de proyecto [10%]; Asistente ingeniero 3 [10%] | 7.2h |  | 469,550 | 469,550 |  |
| 29 | 1.2.5.2 | Realizar levantamiento de estudios en sitio |  | 5d | 2021-12-23 | 2021-12-29 | 28 |  |  | 2021-12-23 | 2021-12-29 | 5d | 0.12d | 0d | Ingeniero de suelos [50%]; Viaje Terrestre [0.1%]; Asistente ingeniero 3 [50%] | 40h |  | 2,500,000 | 2,500,000 |  |
| 30 | 1.2.5.3 | Entregar estudios realizados |  | 7d | 2021-12-29 | 2022-01-06 | 29 |  |  | 2021-12-29 | 2022-01-06 | 7d | 0.12d | 0d | Ingeniero de suelos [50%]; Gerente de proyecto [10%]; Laboratorio de suelos [0.1%] | 33.6h |  | 2,857,500 | 2,857,500 |  |
| 31 | 1.2.6 | **1.2.6 ESPECIES FORESTALES** |  | 11.12d | 2022-01-07 | 2022-01-20 |  |  |  | 2022-01-07 | 2022-01-20 | 11.12d | 0d |  |  | 77.6h |  | 1,777,000 | 1,777,000 |  |
| 32 | 1.2.6.1 | Contratar personal para realizar estudios |  | 3d | 2022-01-07 | 2022-01-08 | 30, 14 |  |  | 2022-01-07 | 2022-01-08 | 3d | 0d |  | Gerente de proyecto [10%]; Asistente administrativo 1 [10%] | 4.8h |  | 132,000 | 132,000 |  |
| 33 | 1.2.6.2 | Analizar especies más representativas para la siembra |  | 5d | 2022-01-08 | 2022-01-14 | 32 |  |  | 2022-01-08 | 2022-01-14 | 5d | 0d |  | Ingeniero ambiental [50%]; Viaje Terrestre [0.1%]; Asistente ingeniero 4 [20%] | 28h |  | 647,500 | 647,500 |  |
| 34 | 1.2.6.3 | Verificar existencia de especies y cantidades a adquirir |  | 7d | 2022-01-14 | 2022-01-20 | 33 |  |  | 2022-01-14 | 2022-01-20 | 7d | 0d |  | Gerente de proyecto [10%]; Ingeniero ambiental [50%]; Asistente administrativo 1 [10%]; Asistente ingeniero 4 [10%] | 44.8h |  | 997,500 | 997,500 |  |
| 35 | 1.2.7 | **1.2.7 ESTUDIOS HIDROLOGICOS** |  | 5.62d | 2021-10-02 A | 2021-10-09 A |  | 100% |  | 2021-10-02 | 2021-10-09 | 5.62d |  |  |  | 81.6h | 81.6h | 1,546,500 | 1,546,500 | 1,546,500 |
| 36 | 1.2.7.1 | Analizar datos históricos del IDEAM |  | 3d | 2021-10-02 A | 2021-10-04 A | 13 | 100% |  | 2021-10-02 | 2021-10-04 | 3d |  |  | Ingeniero para estudios hidrológicos [50%]; Asistente ingeniero 1 [50%] | 24h | 24h | 427,500 | 427,500 | 427,500 |
| 37 | 1.2.7.2 | Entregar de informe de resultados |  | 6d | 2021-10-04 A | 2021-10-09 A | 36 | 100% |  | 2021-10-04 | 2021-10-09 | 6d |  |  | Asistente ingeniero 1 [50%]; Gerente de proyecto [10%]; Ingeniero para estudios hidrológicos [50%]; Asistente administrativo 1 [10%] | 57.6h | 57.6h | 1,119,000 | 1,119,000 | 1,119,000 |
| 38 | 1.2.7.3 | Hito fase 3 | milestone | 0d | 2021-10-09 A | 2021-10-09 A | 37 | 100% |  | 2021-10-09 | 2021-10-09 | 0d |  |  |  |  |  |  |  |  |
| 39 | 1.3 | **1.3 ADECUACION DE TERRENO** |  | 75.38d | 2021-10-02 A | 2022-01-04 |  | 8% | 69.72d | 2021-10-02 | 2022-02-07 | 101.75d | 13.38d |  |  | 960h | 79.2h | 326,574,764 | 326,574,764 | 26,253,375 |
| 40 | 1.3.1 | **1.3.1 ADQUISICION DE TERRENO** |  | 14.38d | 2021-10-02 A | 2021-10-20 |  | 63% | 5.39d | 2021-10-02 | 2021-10-20 | 14.38d | 74.38d |  |  | 115.2h | 79.2h | 29,850,000 | 29,850,000 | 26,253,375 |
| 41 | 1.3.1.1 | Presentar oferta para compra de terreno |  | 6d | 2021-10-02 A | 2021-10-08 A | 13 | 100% |  | 2021-10-02 | 2021-10-08 | 6d |  |  | Asistente administrativo 1 [40%]; Abogado [60%]; Gerente de proyecto [20%]; Computadores [0.1%]; Impresión de planos [0.1%] | 57.6h | 57.6h | 25,000,000 | 25,000,000 | 24,750,000 |
| 42 | 1.3.1.2 | Realizar documentación necesaria con apropiación de la Alcaldía |  | 9d | 2021-10-08 A | 2021-10-20 | 41 | 38% | 5.62d | 2021-10-08 | 2021-10-20 | 9d | 13.75d | 0d | Asistente administrativo 1 [50%]; Gerente de proyecto [30%]; Impresión documentos [0.1%] | 57.6h | 21.6h | 4,850,000 | 4,850,000 | 1,503,375 |
| 43 | 1.3.1.3 | Hito fase 4 | milestone | 0d | 2021-10-20 | 2021-10-20 | 42 |  |  | 2021-10-20 | 2021-10-20 | 0d | 74.38d |  |  |  |  |  |  |  |
| 44 | 1.3.2 | **1.3.2 AISLAMIENTO** |  | 40d | 2021-10-20 | 2021-12-09 |  |  |  | 2021-10-20 | 2021-12-09 | 40d | 34.38d |  |  | 334.4h |  | 181,830,000 | 181,830,000 |  |
| 45 | 1.3.2.1 | Comprar materiales para construcción de aislamiento |  | 11d | 2021-10-20 | 2021-11-08 | 17, 37, 42 |  |  | 2021-10-20 | 2021-11-08 | 11d | 35.5d | 0d | Persona encargada compras [80%]; Asistente ingeniero 1 [50%]; Asistente administrativo 2 [60%] | 121.6h |  | 125,000,000 | 125,000,000 |  |
| 46 | 1.3.2.2 | Movilizar elementos a sitio |  | 4d | 2021-11-08 | 2021-11-11 | 45 |  |  | 2021-11-08 | 2021-11-11 | 4d | 35.12d | 0d | Transporte materiales [0.1%]; Asistente ingeniero 1 [20%]; herramientas manuales [0.1%]; Celular y Radioteléfono [0.1%]; Asistente administrativo 2 [5%] | 4.8h |  | 3,325,000 | 3,325,000 |  |
| 47 | 1.3.2.3 | Contratar personal |  | 10d | 2021-11-11 | 2021-11-20 | 45, 42, 46 |  |  | 2021-11-11 | 2021-11-20 | 10d | 34.38d | 0d | Computadores [0.1%]; Asistente administrativo 1 [50%] | 40h |  | 8,000,000 | 8,000,000 |  |
| 48 | 1.3.2.4 | Construir aislamiento |  | 15d | 2021-11-20 | 2021-12-09 | 47, 46 |  |  | 2021-11-20 | 2021-12-09 | 15d | 34.38d |  | Cuadrilla 1; Gerente de proyecto [50%]; Asistente ingeniero 1 [50%]; Viaje Terrestre [0.1%]; Postes; Alambre; Impresión de planos [0.1%]; Celular y Radioteléfono [0.1%]; herramientas manuales [0.1%] | 168h |  | 45,505,000 | 45,505,000 |  |
| 49 | 1.3.3 | **1.3.3 HECTAREAS REFORESTADAS** |  | 53d | 2021-10-20 | 2021-12-24 |  |  |  | 2021-10-20 | 2022-02-07 | 87.38d | 13.75d |  |  | 484h |  | 103,894,764 | 103,894,764 |  |
| 50 | 1.3.3.1 | Comprar especies forestales |  | 10d | 2021-11-08 | 2021-11-19 | 45 |  |  | 2022-01-20 | 2022-02-02 | 10d | 50.38d | 0d | Gerente de proyecto [50%]; Asistente administrativo 1 [5%]; Asistente ingeniero 1 [20%]; Computadores [0.1%]; Persona encargada compras | 140h |  | 56,000,000 | 56,000,000 |  |
| 51 | 1.3.3.2 | Movilizar especies a sitio |  | 3d | 2021-11-03 | 2021-11-08 | 50SF |  |  | 2022-02-02 | 2022-02-07 | 3d | 60.38d |  | Transporte materiales [0.1%]; Gerente de proyecto [10%]; Asistente administrativo 1 [10%]; Asistente ingeniero 1 [10%]; herramientas manuales [0.1%]; Celular y Radioteléfono [0.1%] | 7.2h |  | 3,000,000 | 3,000,000 |  |
| 52 | 1.3.3.3 | Contratar personal |  | 13d | 2021-10-20 | 2021-11-12 | 42 |  |  | 2021-10-20 | 2021-11-12 | 13d | 13.38d | 0d | Gerente de proyecto [5%]; Computadores [0.1%]; Asistente administrativo 2 [5%] | 10.4h |  | 8,000,000 | 8,000,000 |  |
| 53 | 1.3.3.4 | Preparar el terreno |  | 5d | 2021-11-12 | 2021-11-19 | 52 |  |  | 2021-11-12 | 2021-11-19 | 5d | 13.38d | 0d | Asistente ingeniero 1 [20%]; herramientas manuales [0.1%]; Cuadrilla 1 | 48h |  | 16,250,000 | 16,250,000 |  |
| 54 | 1.3.3.5 | Sembrar especies |  | 29d | 2021-11-19 | 2021-12-24 | 53 |  |  | 2021-11-19 | 2021-12-24 | 29d | 13.38d | 0d | Asistente ingeniero 1 [20%]; herramientas manuales [0.1%]; Celular y Radioteléfono [0.1%]; cuadrilla 2 | 278.4h |  | 20,644,764 | 20,644,764 |  |
| 55 | 1.3.3.6 | Hito fase 5 | milestone | 0d | 2021-12-24 | 2021-12-24 | 54 |  |  | 2021-12-24 | 2021-12-24 | 0d | 21.38d |  |  |  |  |  |  |  |

| ID | WBS | Task | Type | Duration | Start | Finish | Predecessors | Baseline start | Baseline finish | Baseline duration | Total slack | Free slack | Resources | Work | Cost | Baseline cost |
| --- | --- | --- | --- | --- | --- | --- | --- | --- | --- | --- | --- | --- | --- | --- | --- | --- |
| 56 | 1.3.4 | **1.3.4 INFORME FINAL** |  | 8d | 2021-12-24 | 2022-01-04 |  | 2021-12-24 | 2022-01-04 | 8d | 13.38d |  |  | 26.4h | 11,000,000 | 11,000,000 |
| 57 | 1.3.4.1 | Realizar visitas de inspección |  | 3d | 2021-12-24 | 2021-12-29 | 54 | 2021-12-24 | 2021-12-29 | 3d | 13.38d | 0d | Gerente de proyecto [20%]; Viaje Terrestre [0.1%]; Asistente ingeniero 1 [20%]; Computadores [0.1%] | 9.6h | 7,000,000 | 7,000,000 |
| 58 | 1.3.4.2 | Realizar informe final y entrega |  | 7d | 2021-12-29 | 2022-01-04 | 57 | 2021-12-29 | 2022-01-04 | 7d | 13.38d | 0d | Gerente de proyecto [20%]; Asistente ingeniero 1 [5%]; Asistente administrativo 1 [5%] | 16.8h | 4,000,000 | 4,000,000 |
| 59 | 1.4 | **GERENCIA DE PROYECTOS** |  | 0d | 2022-01-04 | 2022-01-04 |  | 2022-01-04 | 2022-01-04 | 0d | 13.38d |  |  |  |  |  |
| 60 | 1.4.1 | fin | milestone | 0d | 2022-01-04 | 2022-01-04 | 58 | 2022-01-04 | 2022-01-04 | 0d | 13.38d |  |  |  |  |  |
